# Cronograma Theoprax

Schedule from MS Project, 2022-05-02 to 2022-12-16.

## Calendars

- Padrão: Mon-Fri 09:00-12:00, 13:00-18:00; Sat-Sun off.

## Schedule

| ID | WBS | Task | Duration | Start | Finish | Predecessors | Total slack | Free slack |
| --- | --- | --- | --- | --- | --- | --- | --- | --- |
| 1 | 1 | **Dashboard de perdas elétricas** | 165d | 2022-05-02 | 2022-12-16 |  |  |  |
| 2 | 1.1 | **1. Captação de recursos** | 48d | 2022-05-02 | 2022-07-06 |  | 10d |  |
| 3 | 1.1.1 | **1.1 Avaliação elétrica da unidade Orlando Gomes** | 30d | 2022-05-02 | 2022-06-10 |  | 10d |  |
| 4 | 1.1.1.1 | 1.1.1 Reunir-se com o setor GTD | 15d | 2022-05-02 | 2022-05-20 |  | 10d | 0d |
| 5 | 1.1.1.2 | 1.1.2 Analisar quantitativo e consumo de medidores e geradores | 15d | 2022-05-23 | 2022-06-10 | 4 | 10d | 0d |
| 6 | 1.1.2 | **1.2 Recebimento dos dados do setor de manutenção** | 6d | 2022-06-13 | 2022-06-20 |  | 10d |  |
| 7 | 1.1.2.1 | 1.2.1 Solicitar envio dos dados | 5d | 2022-06-13 | 2022-06-17 | 5 | 10d | 0d |
| 8 | 1.1.2.2 | 1.2.2 Solicitar assinaturas da autorização de trabalho do projeto | 3d | 2022-06-13 | 2022-06-15 | 5 | 132d |  |
| 9 | 1.1.2.3 | 1.2.3 Receber dados | 1d | 2022-06-20 | 2022-06-20 | 7 | 10d | 0d |
| 10 | 1.1.3 | **1.3 Armazenamento dos dados** | 12d | 2022-06-21 | 2022-07-06 |  | 10d |  |
| 11 | 1.1.3.1 | 1.3.1 Checar dados | 7d | 2022-06-21 | 2022-06-29 | 9 | 10d | 0d |
| 12 | 1.1.3.2 | 1.3.2 Analisar dados | 3d | 2022-06-30 | 2022-07-04 | 11 | 10d | 0d |
| 13 | 1.1.3.3 | 1.3.3 Salvar em nuvem | 2d | 2022-07-05 | 2022-07-06 | 12 | 10d | 0d |
| 14 | 1.2 | **2. Tratamento de dados** | 45d | 2022-07-07 | 2022-09-07 |  | 10d |  |
| 15 | 1.2.1 | **2.1 Elaboração do histórico de consumo** | 38d | 2022-07-07 | 2022-08-29 |  | 10d |  |
| 16 | 1.2.1.1 | 2.1.1 Compilar informações | 3d | 2022-07-07 | 2022-07-11 | 13 | 10d | 0d |
| 17 | 1.2.1.2 | 2.1.2 Criar banco de dados | 25d | 2022-07-12 | 2022-08-15 | 16 | 10d | 0d |
| 18 | 1.2.1.3 | 2.1.3 Dividir dados por prédio/setor/área | 10d | 2022-08-16 | 2022-08-29 | 17 | 10d | 0d |
| 19 | 1.2.2 | **2.2 Filtragem de dados** | 7d | 2022-08-30 | 2022-09-07 |  | 10d |  |
| 20 | 1.2.2.1 | 2.2.1 Parametrizar dados | 7d | 2022-08-30 | 2022-09-07 | 18 | 72d |  |
| 21 | 1.2.2.2 | 2.2.2 Eliminar dados desnecessários | 5d | 2022-08-30 | 2022-09-05 | 18 | 10d | 0d |
| 22 | 1.3 | **3. Planejamento estrutural do dashboard** | 29d | 2022-07-07 | 2022-08-16 |  | 21d |  |
| 23 | 1.3.1 | **3.1 Escolha do software** | 9d | 2022-07-07 | 2022-07-19 |  | 21d |  |
| 24 | 1.3.1.1 | 3.1.1 Analisar custos | 2d | 2022-07-07 | 2022-07-08 | 13 | 21d | 0d |
| 25 | 1.3.1.2 | 3.1.2 Avaliar licenças gratuitas | 7d | 2022-07-11 | 2022-07-19 | 24 | 21d | 0d |

| ID | WBS | Task | Duration | Start | Finish | Predecessors | Total slack | Free slack |
| --- | --- | --- | --- | --- | --- | --- | --- | --- |
| 26 | 1.3.2 | **3.2 Interface UX** | 20d | 2022-07-20 | 2022-08-16 |  | 21d |  |
| 27 | 1.3.2.1 | 3.2.1 Analisar modelos gráficos | 5d | 2022-07-20 | 2022-07-26 | 25 | 103d |  |
| 28 | 1.3.2.2 | 3.2.2 Planejar macros | 10d | 2022-07-20 | 2022-08-02 | 25 | 21d | 0d |
| 29 | 1.3.2.3 | 3.2.3 Verificar usabilidade | 5d | 2022-08-03 | 2022-08-09 | 28 | 93d |  |
| 30 | 1.3.2.4 | 3.2.4 Realizar testes de layout | 10d | 2022-08-03 | 2022-08-16 | 28 | 21d | 0d |
| 31 | 1.4 | **4. Elaboração do dashboard** | 56d | 2022-08-17 | 2022-11-02 |  | 21d |  |
| 32 | 1.4.1 | **4.1 Criação de protótipos** | 16d | 2022-08-17 | 2022-09-07 |  | 21d |  |
| 33 | 1.4.1.1 | 4.1.1 Simular layouts | 7d | 2022-08-17 | 2022-08-25 | 30 | 21d | 0d |
| 34 | 1.4.1.2 | 4.1.2 Escolher modelo definitivo | 2d | 2022-08-26 | 2022-08-29 | 33 | 21d | 0d |
| 35 | 1.4.1.3 | 4.1.3 Realizar testes com banco de dados reduzido | 7d | 2022-08-30 | 2022-09-07 | 34 | 21d | 0d |
| 36 | 1.4.2 | **4.2 Desenvolvimento do modelo final** | 40d | 2022-09-08 | 2022-11-02 |  | 21d |  |
| 37 | 1.4.2.1 | 4.2.1 Aplicar banco de dados completo | 30d | 2022-09-08 | 2022-10-19 | 35 | 21d | 0d |
| 38 | 1.4.2.2 | 4.2.2 Analisar a estruturação | 3d | 2022-10-20 | 2022-10-24 | 37 | 21d | 0d |
| 39 | 1.4.2.3 | 4.2.3 Testar a funcionalidade | 7d | 2022-10-25 | 2022-11-02 | 38 | 21d | 0d |
| 40 | 1.5 | **5. Finalização do projeto** | 64d | 2022-09-06 | 2022-12-02 |  | 10d |  |
| 41 | 1.5.1 | **5.1 Documentação final** | 63d | 2022-09-06 | 2022-12-01 |  | 10d |  |
| 42 | 1.5.1.1 | 5.1.1 Elaborar o artigo | 53d | 2022-09-06 | 2022-11-17 | 21 | 10d | 0d |
| 43 | 1.5.1.2 | 5.1.2 Revisar artigo | 7d | 2022-11-18 | 2022-11-28 | 42 | 13d | 0d |
| 44 | 1.5.1.3 | 5.1.3 Elaborar o slide | 10d | 2022-11-18 | 2022-12-01 | 42 | 10d | 0d |
| 45 | 1.5.2 | **5.2 Envio de entregáveis** | 22d | 2022-11-03 | 2022-12-02 |  | 10d |  |
| 46 | 1.5.2.1 | 5.2.1 Finalizar dashboard | 3d | 2022-11-03 | 2022-11-07 | 39 | 29d |  |
| 47 | 1.5.2.2 | 5.2.2 Entregar o artigo | 1d | 2022-11-29 | 2022-11-29 | 43 | 13d |  |
| 48 | 1.5.2.3 | 5.3.3 Realizar a apresentação final | 1d | 2022-12-02 | 2022-12-02 | 44 | 10d |  |
| 49 | 1.5.3 | **5.3 Conclusões finais** | 11d | 2022-11-03 | 2022-11-17 |  | 21d |  |
| 50 | 1.5.3.1 | 5.3.1 Avaliar as soluções propostas | 11d | 2022-11-03 | 2022-11-17 | 39 | 21d |  |
| 51 | 1.5.3.2 | 5.3.2 Analisar as possíveis melhorias | 11d | 2022-11-03 | 2022-11-17 | 39 | 21d |  |
